Schedule from GanttProject, 2019-10-07 to 2019-10-28.

## Calendars

- Project calendar: Mon-Fri working; Sat-Sun off.

## Resources

| Resource |
| --- |
| SwissTPH - Dragos |
| Soldevelo |
| Bluesquare |
| SwissTPH - Patrick |

## Schedule

| ID | WBS | Task | Duration | Start | Finish | Predecessors | Resources |
| --- | --- | --- | --- | --- | --- | --- | --- |
| 1 | 1 | **October release** | 16d | 2019-10-07 | 2019-10-28 |  |  |
| 2 | 1.1 | Database scripts | 2d | 2019-10-07 | 2019-10-08 |  | Soldevelo |
| 3 | 1.2 | **Legacy (WebApp and API)** | 4d | 2019-10-09 | 2019-10-14 | 2 |  |
| 4 | 1.2.1 | Deliver new code in release branch | 1d | 2019-10-09 | 2019-10-09 |  |  |
| 5 | 1.2.2 | Test release branch | 1d | 2019-10-10 | 2019-10-10 | 4 |  |
| 6 | 1.2.3 | Build/publish ASP package | 1d | 2019-10-11 | 2019-10-11 | 5 |  |
| 7 | 1.2.4 | Releasing in github | 1d | 2019-10-14 | 2019-10-14 | 6 | SwissTPH - Dragos; Soldevelo |
| 8 | 1.3 | Mobile Apps Demo APK (Claims and Policies) | 1d | 2019-10-15 | 2019-10-15 | 3 | SwissTPH - Dragos |
| 9 | 1.4 | **Modular** | 1d | 2019-10-14 | 2019-10-14 | 2 |  |
| 10 | 1.4.1 | Core + Claims pip and nmp release | 1d | 2019-10-14 | 2019-10-14 |  |  |
| 11 | 1.4.2 | FHIR release | 1d | 2019-10-14 | 2019-10-14 |  |  |
| 12 | 1.5 | **UAT** | 5d | 2019-10-21 | 2019-10-25 |  |  |
| 13 | 1.5.1 | Testing Web App (Modular + legacy) | 5d | 2019-10-21 | 2019-10-25 | 18, 19, 20 | SwissTPH - Patrick |
| 14 | 1.5.2 | Testing Mobile Apps | 1d | 2019-10-23 | 2019-10-23 | 7 | SwissTPH - Dragos |
| 15 | 1.6 | **Closing** | 10d | 2019-10-15 | 2019-10-28 |  |  |
| 16 | 1.6.1 | **Demo server** | 2d | 2019-10-15 | 2019-10-16 |  |  |
| 17 | 1.6.1.1 | Deploy database | 1d | 2019-10-15 | 2019-10-15 | 2FS+3d |  |
| 18 | 1.6.1.2 | Deploy WebApp and API package | 1d | 2019-10-16 | 2019-10-16 | 3, 17 |  |
| 19 | 1.6.1.3 | Deploy modulare BE | 1d | 2019-10-15 | 2019-10-15 | 9 |  |
| 20 | 1.6.1.4 | Deploy modulare FE | 1d | 2019-10-16 | 2019-10-16 | 19 |  |
| 21 | 1.6.2 | Documentations | 4d | 2019-10-22 | 2019-10-25 | 13SS+1d | SwissTPH - Patrick |
| 22 | 1.6.3 | Wiki (release notes, ticket updates) | 1d | 2019-10-28 | 2019-10-28 | 12 |  |
| 23 | 1.6.4 | Docker | 1d | 2019-10-21 | 2019-10-21 | 9 | SwissTPH - Patrick |
